# Ny butik i Aarhus

Schedule from MS Project, 2019-06-20 to 2019-07-25, costs in kr.

## Calendars

- Standard: Mon-Fri 08:00-12:00, 13:00-17:00; Sat-Sun off.

## Resources

| Resource | Unit | Rate |
| --- | --- | --- |
| Arkitekt Arne |  | 600 |
| Murer Mads |  | 450 |
| Jord og Beton Jette |  | 400 |
| Tømrer Tom |  | 475 |
| Snedker Susanne |  | 450 |
| Maler Morten |  | 450 |
| VVS Victoria |  | 450 |
| Gravemaskine |  | 600 |
| Betonblander |  | 150 |
| Maling | Liter | 200 |
| Beton | Kubikmeter | 1100 |
| Mødeforplejning | Kuverter | 50 |
| Kontorarktikler |  |  |

## Schedule

| ID | WBS | Task | Type | Duration | Start | Finish | Predecessors | Total slack | Free slack | Cost |
| --- | --- | --- | --- | --- | --- | --- | --- | --- | --- | --- |
| 1 | 1 | Tegning |  | 3d | 2019-06-20 | 2019-06-24 |  | 0d |  |  |
| 2 | 2 | **Fundament** |  | 8d | 2019-06-25 | 2019-07-04 | 1 | 0d |  | 1,000 |
| 3 | 2.1 | Udgravning |  | 2d | 2019-06-25 | 2019-06-26 |  | 0d |  |  |
| 4 | 2.2 | Støbning |  | 1d | 2019-06-27 | 2019-06-27 | 3 | 0d |  | 1,000 |
| 5 | 2.3 | Afbinding |  | 5d | 2019-06-28 | 2019-07-04 | 4 | 0d |  |  |
| 6 | 3 | **Råhus** |  | 5d | 2019-07-05 | 2019-07-11 | 2 | 0d |  | 35,000 |
| 7 | 3.1 | Bærende konstruktioner |  | 3d | 2019-07-05 | 2019-07-09 |  | 0d |  |  |
| 8 | 3.2 | Ydervægge |  | 2d | 2019-07-10 | 2019-07-11 | 7 | 0d |  | 15,000 |
| 9 | 3.3 | Tagkonstruktioner |  | 2d | 2019-07-10 | 2019-07-11 | 8SS | 0d |  | 20,000 |
| 10 | 4 | Rejsegilde | milestone | 0d | 2019-07-11 | 2019-07-11 | 6 | 0d |  |  |
| 11 | 5 | Taglægning |  | 10d | 2019-07-12 | 2019-07-25 | 10 | 0d |  |  |
| 12 | 6 | Døre og vinduer |  | 2d | 2019-07-12 | 2019-07-15 | 11SS | 5d | 0d |  |
| 13 | 7 | Faskine |  | 2d | 2019-06-27 | 2019-06-28 | 3 | 17.12d | 9d |  |
| 14 | 8 | Tagrender |  | 5h | 2019-07-12 | 2019-07-12 | 13, 12SS | 8.12d |  |  |
| 15 | 9 | Maling udvendigt |  | 10h | 2019-07-24 | 2019-07-25 | 14, 11FF | 0d |  |  |
| 16 | 10 | Maling indvendigt |  | 2d | 2019-07-16 | 2019-07-17 | 12 | 5d | 0d |  |
| 17 | 11 | Gulv |  | 1d | 2019-07-18 | 2019-07-18 | 16 | 5d |  |  |
| 18 | 12 | Indvielse | milestone | 0d | 2019-07-25 | 2019-07-25 | 17, 15 | 0d |  |  |
