# Husrenovering

Schedule from MS Project, 2019-11-08 to 2019-12-02, costs in kr..

## Calendars

- Standard: Mon-Fri 08:00-12:00, 13:00-17:00; Sat-Sun off.

## Resources

| Resource | Unit | Rate |
| --- | --- | --- |
| VVS Victoria |  | 300 |
| VVS Victor |  | 300 |
| Pexslanger | Meter | 15 |
| Samlestykke | Stk. | 40 |
| Rørholder | Stk. | 10 |
| Maler Morten |  | 230 |
| Maler Mille |  | 230 |
| Vægmaling glans 10 | Spande | 800 |
| Loftmaling glans 5 | Spande | 600 |
| Spartel | Spande | 150 |
| VVS dimser |  |  |
| Pensler og ruller |  |  |
| Filt | Ruller | 200 |

## Schedule

| ID | WBS | Task | Type | Duration | Start | Finish | Predecessors | Total slack | Resources | Work | Cost |
| --- | --- | --- | --- | --- | --- | --- | --- | --- | --- | --- | --- |
| 1 | 1 | **Maling** |  | 12d | 2019-11-08 | 2019-11-25 |  | 0d |  | 112h | 39,660 |
| 2 | 1.1 | Spartling |  | 2d | 2019-11-08 | 2019-11-11 |  | 0d | Maler Mille; Spartel [6 Spande] | 16h | 4,580 |
| 3 | 1.2 | Afslibning |  | 2d | 2019-11-12 | 2019-11-13 | 2 | 0d | Maler Morten | 16h | 3,680 |
| 4 | 1.3 | Opsætning af filt |  | 3d | 2019-11-14 | 2019-11-18 | 3 | 0d | Filt [4 Ruller]; Maler Mille | 24h | 6,320 |
| 5 | 1.4 | Maling af stueetage |  | 5d | 2019-11-19 | 2019-11-25 | 4 | 0d | Maler Mille; Loftmaling glans 5 [4 Spande]; Vægmaling glans 10 [6 Spande] | 40h | 16,400 |
| 6 | 1.5 | Maling af 1. sal |  | 2d | 2019-11-19 | 2019-11-20 | 5SS | 0d | Maler Morten; Loftmaling glans 5 [3 Spande]; Vægmaling glans 10 [4 Spande] | 16h | 8,680 |
| 7 | 2 | **VVS** |  | 8d | 2019-11-21 | 2019-12-02 |  | 0d |  | 48h | 18,990 |
| 8 | 2.1 | Montering af nyt gasfyr |  | 2d | 2019-11-21 | 2019-11-22 | 6 | 0d | VVS Victoria; VVS dimser [0.1%]; Samlestykke [6 Stk.] | 16h | 5,390 |
| 9 | 2.2 | Montering af varmtvandsbeholder |  | 1d | 2019-11-25 | 2019-11-25 | 8 | 0d | VVS Victoria; VVS Victor; Rørholder [4 Stk.]; VVS dimser [0.1%]; Samlestykke [4 Stk.] | 16h | 5,400 |
| 10 | 2.3 | Montering af pexslanger |  | 3d | 2019-11-26 | 2019-11-28 | 9 | 0d | Pexslanger [80 Meter]; Rørholder [14 Stk.]; Samlestykke [20 Stk.]; VVS dimser [0.1%] |  | 2,640 |
| 11 | 2.4 | Montering af radiatorer |  | 2d | 2019-11-29 | 2019-12-02 | 10 | 0d | VVS Victor; Rørholder [8 Stk.]; Samlestykke [12 Stk.]; VVS dimser [0.1%] | 16h | 5,560 |
| 12 | 3 | Afslutning | milestone | 0d | 2019-12-02 | 2019-12-02 | 11 | 0d |  |  |  |
