# Renovering af nyt hus

Schedule from MS Project, 2019-06-17 to 2019-07-24, status date 2019-06-16, costs in kr., A marks actual dates.

## Calendars

- Standard: Mon-Fri 08:00-12:00, 13:00-17:00; Sat-Sun off.

## Resources

| Resource | Rate |
| --- | --- |
| Arne | 200 |
| Lotte | 100 |
| Rikke | 50 |
| Peter | 200 |
| Tom | 150 |
| Ib | 100 |
| Søren | 200 |
| Kurt | 150 |

## Schedule

| ID | WBS | Task | Type | Duration | Start | Finish | Predecessors | Complete | Remaining | Baseline start | Baseline finish | Baseline duration | Total slack | Free slack | Resources | Work | Actual work | Cost | Baseline cost | Actual cost |
| --- | --- | --- | --- | --- | --- | --- | --- | --- | --- | --- | --- | --- | --- | --- | --- | --- | --- | --- | --- | --- |
| 1 | 1 | **Maling** |  | 1d | 2019-06-17 A | 2019-06-17 A |  | 100% |  | 2019-06-17 | 2019-06-17 | 1d |  |  |  | 8h | 8h | 1,600 | 1,600 | 1,600 |
| 2 | 1.1 | Bestille maling |  | 1d | 2019-06-17 A | 2019-06-17 A |  | 100% |  | 2019-06-17 | 2019-06-17 | 1d |  |  | Søren | 8h | 8h | 1,600 | 1,600 | 1,600 |
| 3 | 1.2 | Bestille pensler + afdækning |  | 1d | 2019-06-17 A | 2019-06-17 A | 2SS | 100% |  | 2019-06-17 | 2019-06-17 | 1d |  |  |  |  |  |  |  |  |
| 4 | 1.3 | Bestillinger er klaret | milestone | 0d | 2019-06-17 A | 2019-06-17 A | 3 | 100% |  | 2019-06-17 | 2019-06-17 | 0d |  |  |  |  |  |  |  |  |
| 5 | 2 | **Male** |  | 17d | 2019-06-18 A | 2019-07-10 | 2 | 49% | 8.67d | 2019-06-18 | 2019-07-10 | 17d | 10d |  |  | 196h | 96h | 27,400 | 23,800 | 13,600 |
| 6 | 2.1 | Stueplan |  | 5d | 2019-06-18 A | 2019-06-24 |  | 40% | 3d | 2019-06-18 | 2019-06-21 | 4d | 0d |  | Arne | 40h | 16h | 8,000 | 6,400 | 3,200 |
| 7 | 2.2 | 1. sal |  | 4d | 2019-06-24 A | 2019-06-27 | 6 | 25% | 3d | 2019-06-24 | 2019-06-26 | 3d | 1d | 0d | Lotte | 32h | 8h | 3,200 | 2,400 | 800 |
| 8 | 2.3 | Kælder |  | 3d | 2019-06-27 A | 2019-07-01 | 7 | 67% | 1d | 2019-06-27 | 2019-07-01 | 3d | 17d |  | Ib | 24h | 16h | 2,400 | 2,400 | 1,600 |
| 9 | 2.4 | Garage |  | 2d | 2019-07-02 A | 2019-07-03 A | 8 | 100% |  | 2019-07-02 | 2019-07-03 | 2d |  |  | Peter | 16h | 16h | 3,200 | 3,200 | 3,200 |
| 10 | 2.5 | Facade |  | 5d | 2019-07-04 A | 2019-07-10 | 9 | 60% | 2d | 2019-07-04 | 2019-07-10 | 5d | 10d |  | Ib | 40h | 24h | 4,000 | 4,000 | 2,400 |
| 11 | 2.6 | Vinduesrammer |  | 5d | 2019-07-02 A | 2019-07-08 | 9SS | 40% | 3d | 2019-07-02 | 2019-07-05 | 4d | 11.5d | 0d | Tom | 40h | 16h | 6,000 | 4,800 | 2,400 |
| 12 | 2.7 | Kontrollere malearbejde |  | 0.5d | 2019-07-09 | 2019-07-09 | 11 |  |  | 2019-07-08 | 2019-07-08 | 0.5d | 11.5d | 0d | Tom | 4h |  | 600 | 600 |  |
| 13 | 2.8 | Færdigmalet | milestone | 0d | 2019-07-09 | 2019-07-09 | 12 |  |  | 2019-07-08 | 2019-07-08 | 0d | 11.5d |  |  |  |  |  |  |  |
| 14 | 3 | **Ordne have** |  | 14d | 2019-06-18 A | 2019-07-05 | 4 | 36% | 9d | 2019-06-18 | 2019-07-04 | 12.5d | 13d |  |  | 112h | 40h | 15,200 | 13,400 | 5,600 |
| 15 | 3.1 | Beskære træer |  | 2d | 2019-06-18 | 2019-06-19 |  |  |  | 2019-06-18 | 2019-06-19 | 2d | 21d | 0d | Tom | 16h |  | 2,400 | 2,400 |  |
| 16 | 3.2 | Beskære buske |  | 2d | 2019-06-20 | 2019-06-21 | 15 |  |  | 2019-06-20 | 2019-06-21 | 2d | 21d | 0d | Tom | 16h |  | 2,400 | 2,400 |  |
| 17 | 3.3 | Bortkøre beskæringer |  | 2d | 2019-06-24 | 2019-06-25 | 16 |  |  | 2019-06-24 | 2019-06-25 | 2d | 21d |  | Peter | 16h |  | 3,200 | 3,200 |  |
| 18 | 3.4 | Male træterrasse |  | 3d | 2019-06-26 A | 2019-06-28 A | 17 | 100% |  | 2019-06-26 | 2019-06-27 | 2d |  |  | Arne | 24h | 24h | 4,800 | 3,200 | 4,800 |
| 19 | 3.5 | Reparere hegn |  | 4d | 2019-07-01 A | 2019-07-04 | 18 | 50% | 2d | 2019-06-28 | 2019-07-03 | 3.5d | 0d |  | Rikke | 32h | 16h | 1,600 | 1,400 | 800 |
| 20 | 3.6 | Male hegn |  | 1d | 2019-07-05 | 2019-07-05 | 19 |  |  | 2019-07-03 | 2019-07-04 | 1d | 0d |  | Lotte | 8h |  | 800 | 800 |  |
| 21 | 3.7 | Haven er klar | milestone | 0d | 2019-07-05 | 2019-07-05 | 20 |  |  | 2019-07-04 | 2019-07-04 | 0d | 0d |  |  |  |  |  |  |  |
| 22 | 4 | **Fliseterrasse** |  | 9d | 2019-07-08 A | 2019-07-18 | 21 | 5% | 8.53d | 2019-07-04 | 2019-07-17 | 9d | 0d |  |  | 204h | 4h | 31,600 | 31,600 | 800 |
| 23 | 4.1 | Bestille grus og fliser |  | 0.5d | 2019-07-08 A | 2019-07-08 A | 4 | 100% |  | 2019-07-04 | 2019-07-04 | 0.5d |  |  | Arne | 4h | 4h | 800 | 800 | 800 |
| 24 | 4.2 | Afrette grus |  | 2d | 2019-07-08 | 2019-07-09 | 23SS |  |  | 2019-07-04 | 2019-07-08 | 2d | 0d |  | Søren; Kurt | 32h |  | 5,600 | 5,600 |  |
| 25 | 4.3 | Lægge fliser |  | 7d | 2019-07-10 | 2019-07-18 | 24 |  |  | 2019-07-08 | 2019-07-17 | 7d | 0d |  | Peter; Rikke; Søren | 168h |  | 25,200 | 25,200 |  |
| 26 | 4.4 | Fliselægning udført | milestone | 0d | 2019-07-18 | 2019-07-18 | 25 |  |  | 2019-07-17 | 2019-07-17 | 0d | 0d |  |  |  |  |  |  |  |
| 27 | 5 | Indflytning | milestone | 4d | 2019-07-19 | 2019-07-24 | 22 |  |  | 2019-07-17 | 2019-07-23 | 4d | 0d |  |  |  |  |  |  |  |
