# Ny butik i Århus

Schedule from MS Project, 2018-03-05 to 2018-04-12, costs in kr..
4D

## Calendars

- Standard: Mon-Fri 08:00-12:00, 13:00-17:00; Sat-Sun off.

## Resources

| Resource | Rate | Cost per use | Notes |
| --- | --- | --- | --- |
| Arkitekt Arne | 600 |  |  |
| Murer Mads | 472.5 |  | Du stiger i løn fra 6/-2018 |
| Jord og beton Jette | 420 |  | Du stiger i løn fra 6/-2018 |
| Tømrer Tom | 475 |  |  |
| Snedker Susanne | 475 |  |  |
| Maler Morten | 472.5 |  | Du stiger i løn fra 6/-2018 |
| VVS Victoria | 472.5 |  | Du stiger i løn fra 6/-2018 |
| Gravemaskine | 600 | 2000 |  |
| Betonblander | 150 | 1200 |  |

## Schedule

| ID | WBS | Task | Type | Duration | Start | Finish | Predecessors | Total slack | Free slack | Resources | Work | Cost |
| --- | --- | --- | --- | --- | --- | --- | --- | --- | --- | --- | --- | --- |
| 1 | 1 | Tegning |  | 3d | 2018-03-05 | 2018-03-09 |  | 0d |  | Arkitekt Arne | 24h | 14,400 |
| 2 | 2 | **Fundament** |  | 6d | 2018-03-13 | 2018-03-21 | 1FS+2d | 0d |  |  | 48h | 24,600 |
| 3 | 2.1 | Udgravning |  | 2d | 2018-03-13 | 2018-03-15 |  | 0d |  | Gravemaskine; Jord og beton Jette | 32h | 18,000 |
| 4 | 2.2 | Støbning |  | 1d | 2018-03-15 | 2018-03-16 | 3 | 0d |  | Jord og beton Jette; Betonblander | 16h | 6,600 |
| 5 | 2.3 | Afbinding |  | 5ed | 2018-03-16 | 2018-03-21 | 4 | 0d |  |  |  |  |
| 6 | 3 | **Råhus** |  | 4.5d | 2018-03-21 | 2018-03-28 | 5 | 0d |  |  | 56h | 61,200 |
| 7 | 3.1 | Bærende konstruktioner |  | 3d | 2018-03-21 | 2018-03-26 |  | 0d |  | Tømrer Tom | 24h | 11,400 |
| 8 | 3.2 | Ydervægge |  | 2d | 2018-03-26 | 2018-03-27 | 7FS-2.5% | 0d |  | Murer Mads | 16h | 22,200 |
| 9 | 3.3 | Tagkonstruktioner |  | 2d | 2018-03-26 | 2018-03-28 | 8SS | 0d |  | Snedker Susanne | 16h | 27,600 |
| 10 | 4 | Rejsegilde | milestone | 0d | 2018-03-28 | 2018-03-28 | 9 | 0d |  | Arkitekt Arne; Jord og beton Jette; Maler Morten; Murer Mads; Snedker Susanne; Tømrer Tom; VVS Victoria |  |  |
| 11 | 5 | Taglægning |  | 10d | 2018-03-28 | 2018-04-11 | 10 | 0d |  | Tømrer Tom | 80h | 38,000 |
| 12 | 6 | Døre og vinduer |  | 2d | 2018-03-28 | 2018-03-30 | 11SS | 4.5d | 0d | Snedker Susanne | 16h | 7,600 |
| 13 | 7 | Faskine |  | 2d | 2018-03-16 | 2018-03-20 | 4 | 11.12d | 5.5d | Gravemaskine; Jord og beton Jette | 32h | 18,000 |
| 14 | 8 | Tagrender |  | 5h | 2018-03-28 | 2018-03-28 | 13, 12SS | 5.62d | 0d | VVS Victoria | 5h | 2,250 |
| 15 | 9 | Maling udvendigt |  | 10h | 2018-03-28 | 2018-03-30 | 14 | 5.62d | 1d | Maler Morten | 10h | 4,500 |
| 16 | 10 | Gulv |  | 1d | 2018-03-30 | 2018-04-02 | 15FS-5%, 12 | 4.62d |  | Snedker Susanne | 8h | 3,800 |
| 17 | 11 | Maling indvendigt |  | 2d | 2018-04-09 | 2018-04-11 | 16, 11FF | 0d |  | Maler Morten | 16h | 7,560 |
| 18 | 12 | Indvielse | milestone | 0d | 2018-04-12 | 2018-04-12 | 17FS+1d | 0d |  | Jord og beton Jette; Maler Morten; Murer Mads; Snedker Susanne; Tømrer Tom; VVS Victoria; Arkitekt Arne |  |  |
