# Ny butik på Amagertorv

Schedule from MS Project, 2017-09-23 to 2017-10-30, costs in kr.
VideoBuster A/S
Projektplan over byggeriet af den nye butik på Amagertorv. Butikken forventes klar til indvielse om to måneder.

## Calendars

- Standard: Mon-Fri 08:00-12:00, 13:00-17:00; Sat-Sun off.

## Resources

| Resource | Rate | Cost per use | Notes |
| --- | --- | --- | --- |
| Murer Mads | 472.5 |  | Der er indgående aftale om lønstigning på 5% med virkning fra 1 måned fra projektets startdato. |
| Jord og beton Jette | 420 |  | Der er indgående aftale om lønstigning på 5% med virkning fra 1 måned fra projektets startdato. |
| Tømrer Tom | 475 |  |  |
| Snedker Susanne | 475 |  |  |
| Maler Morten | 472.5 |  | Der er indgående aftale om lønstigning på 5% med virkning fra 1 måned fra projektets startdato. |
| VVS Victoria | 472.5 |  | Der er indgående aftale om lønstigning på 5% med virkning fra 1 måned fra projektets startdato. |
| Gravemaskine | 600 | 2000 |  |
| Betonblander | 150 | 1200 |  |
| Arkitekt Arne | 600 |  |  |

## Schedule

| ID | WBS | Task | Type | Duration | Start | Finish | Predecessors | Total slack | Free slack | Resources | Work | Cost |
| --- | --- | --- | --- | --- | --- | --- | --- | --- | --- | --- | --- | --- |
| 1 | 1 | Start | milestone | 0d | 2017-09-23 | 2017-09-23 |  | 1d | 0d |  |  |  |
| 2 | 2 | Tegning |  | 3d | 2017-09-25 | 2017-09-27 | 1 | 1d | 0d | Arkitekt Arne | 24h | 14,400 |
| 3 | 3 | **Fundament** |  | 7d | 2017-09-28 | 2017-10-07 | 2 | 0d |  |  | 24h | 15,030 |
| 4 | 3.1 | Udgravning |  | 2d | 2017-09-28 | 2017-09-29 |  | 1d | 0d | Jord og beton Jette; Gravemaskine | 16h | 9,320 |
| 5 | 3.2 | Støbning |  | 1d | 2017-10-02 | 2017-10-02 | 4 | 1d | 0d | Jord og beton Jette; Betonblander | 8h | 5,710 |
| 6 | 3.3 | Afbinding |  | 5ed | 2017-10-02 | 2017-10-07 | 5 | 4.88d |  |  |  |  |
| 7 | 4 | **Råhus** |  | 4.5d | 2017-10-09 | 2017-10-13 | 6 | 0d |  |  | 56h | 61,560 |
| 8 | 4.1 | Bærende konstruktioner |  | 3d | 2017-10-09 | 2017-10-11 |  | 0d |  | Tømrer Tom | 24h | 11,400 |
| 9 | 4.2 | Ydervægge |  | 2d | 2017-10-11 | 2017-10-13 | 8FS-2.5% | 0d |  | Murer Mads | 16h | 22,560 |
| 10 | 4.3 | Tag |  | 2d | 2017-10-11 | 2017-10-13 | 9SS | 0d |  | Snedker Susanne | 16h | 27,600 |
| 11 | 5 | Rejsegilde | milestone | 0d | 2017-10-13 | 2017-10-13 | 10, 9 | 0d |  | Jord og beton Jette; Maler Morten; Murer Mads; Snedker Susanne; Tømrer Tom; VVS Victoria |  |  |
| 12 | 6 | Taglægning |  | 10d | 2017-10-13 | 2017-10-27 | 11 | 0d |  | Tømrer Tom | 80h | 38,000 |
| 13 | 7 | Døre og vinduer |  | 2d | 2017-10-13 | 2017-10-17 | 12SS | 4.62d | 0d | Snedker Susanne | 16h | 7,600 |
| 14 | 8 | Faskine |  | 2d | 2017-10-03 | 2017-10-04 | 5 | 12.12d | 6.5d | Jord og beton Jette; Gravemaskine | 16h | 9,320 |
| 15 | 9 | Tagrender |  | 5h | 2017-10-13 | 2017-10-16 | 14, 13SS | 5.62d | 0d | VVS Victoria | 5h | 2,362.5 |
| 16 | 10 | Maling udvendigt |  | 10h | 2017-10-16 | 2017-10-17 | 15 | 5.62d | 1d | Maler Morten | 10h | 4,725 |
| 17 | 11 | Gulv |  | 1d | 2017-10-17 | 2017-10-18 | 16FS-5%, 13 | 4.62d |  | Snedker Susanne | 8h | 3,800 |
| 18 | 12 | Maling indvendigt |  | 2d | 2017-10-25 | 2017-10-27 | 17, 12FF | 0d |  | Maler Morten | 16h | 7,560 |
| 19 | 13 | Indvielse | milestone | 0d | 2017-10-30 | 2017-10-30 | 18FS+1d, 13 | 0d |  | Jord og beton Jette; Maler Morten; Murer Mads; Snedker Susanne; Tømrer Tom; VVS Victoria |  |  |
