# Ny butik i Århus

Schedule from MS Project, 2017-07-21 to 2017-08-28, costs in kr.
VideoBuster A/S
Projektplan over byggeriet af den nye butik i Århus. Butikken forventes klar til indvielse om to måneder.

## Calendars

- Standard: Mon-Fri 08:00-12:00, 13:00-17:00; Sat-Sun off.

## Resources

| Resource | Rate | Cost per use | Notes |
| --- | --- | --- | --- |
| Arkitekt Arne | 600 |  |  |
| Murer Mads | 450 |  | Der er indgående aftale om lønstigning på 5% med virkning fra 1 måned fra projektets startdato. |
| Jord og beton Jette | 400 |  | Der er indgående aftale om lønstigning på 5% med virkning fra 1 måned fra projektets startdato. |
| Tømrer Tom | 475 |  |  |
| Snedker Susanne | 475 |  |  |
| Maler Morten | 450 |  | Der er indgående aftale om lønstigning på 5% med virkning fra 1 måned fra projektets startdato. |
| VVS Victoria | 450 |  | Der er indgående aftale om lønstigning på 5% med virkning fra 1 måned fra projektets startdato. |
| Gravemaskine | 600 | 2000 |  |
| Betonblander | 150 | 1200 |  |

## Schedule

| ID | WBS | Task | Type | Duration | Start | Finish | Predecessors | Total slack | Free slack | Resources | Work | Cost |
| --- | --- | --- | --- | --- | --- | --- | --- | --- | --- | --- | --- | --- |
| 1 | 1 | start | milestone | 0d | 2017-07-21 | 2017-07-21 |  | 0.38d | 0.25d |  |  |  |
| 2 | 2 | Tegning |  | 3d | 2017-07-21 | 2017-07-27 | 1 | 0.12d | 0d | Arkitekt Arne | 24h | 14,400 |
| 3 | 3 | **Fundament** |  | 6.25d | 2017-07-27 | 2017-08-06 | 2 | 0d |  |  | 24h | 15,030 |
| 4 | 3.1 | Udgravning |  | 2d | 2017-07-27 | 2017-07-31 |  | 0.25d | 0d | Jord og beton Jette; Gravemaskine | 16h | 9,320 |
| 5 | 3.2 | Støbning |  | 1d | 2017-07-31 | 2017-08-01 | 4 | 0.25d | 0d | Jord og beton Jette; Betonblander | 8h | 5,710 |
| 6 | 3.3 | Afbinding |  | 5ed | 2017-08-01 | 2017-08-06 | 5 | 2.12d |  |  |  |  |
| 7 | 4 | **Råhus** |  | 4.5d | 2017-08-07 | 2017-08-11 | 6 | 0d |  |  | 56h | 61,560 |
| 8 | 4.1 | Bærende konstruktioner |  | 3d | 2017-08-07 | 2017-08-09 |  | 0d |  | Tømrer Tom | 24h | 11,400 |
| 9 | 4.2 | Ydervægge |  | 2d | 2017-08-09 | 2017-08-11 | 8FS-2.5% | 0d |  | Murer Mads | 16h | 22,560 |
| 10 | 4.3 | Tag |  | 2d | 2017-08-09 | 2017-08-11 | 9SS | 0d |  | Snedker Susanne | 16h | 27,600 |
| 11 | 5 | Rejsegilde | milestone | 0d | 2017-08-11 | 2017-08-11 | 10, 9 | 0d |  | Arkitekt Arne; Jord og beton Jette; Maler Morten; Murer Mads; Snedker Susanne; Tømrer Tom; VVS Victoria |  |  |
| 12 | 6 | Taglægning |  | 10d | 2017-08-11 | 2017-08-25 | 11 | 0d |  | Tømrer Tom | 80h | 38,000 |
| 13 | 7 | Døre og vinduer |  | 2d | 2017-08-11 | 2017-08-15 | 12SS | 4.62d | 0d | Snedker Susanne | 16h | 7,600 |
| 14 | 8 | Faskine |  | 2d | 2017-08-01 | 2017-08-03 | 5 | 11.38d | 5.75d | Jord og beton Jette; Gravemaskine | 16h | 9,320 |
| 15 | 9 | Tagrender |  | 5h | 2017-08-11 | 2017-08-14 | 14, 13SS | 5.62d | 0d | VVS Victoria | 5h | 2,362.5 |
| 16 | 10 | Maling udvendigt |  | 10h | 2017-08-14 | 2017-08-15 | 15 | 5.62d | 1d | Maler Morten | 10h | 4,725 |
| 17 | 11 | Gulv |  | 1d | 2017-08-15 | 2017-08-16 | 16FS-5%, 13 | 4.62d |  | Snedker Susanne | 8h | 3,800 |
| 18 | 12 | Maling indvendigt |  | 2d | 2017-08-23 | 2017-08-25 | 17, 12FF | 0d |  | Maler Morten | 16h | 7,560 |
| 19 | 13 | Indvielse | milestone | 0d | 2017-08-28 | 2017-08-28 | 18FS+1d, 13 | 0d |  | Arkitekt Arne; Jord og beton Jette; Maler Morten; Murer Mads; Snedker Susanne; Tømrer Tom; VVS Victoria |  |  |
