# Ny butik

Schedule from MS Project, 2013-08-26 to 2013-09-30, costs in kr..
VideoBuster A/S

## Calendars

- Standard: Mon-Fri 08:00-12:00, 13:00-17:00; Sat-Sun off.

## Resources

| Resource |
| --- |
| Arkitekt Arne |
| Jord og beton Jette |
| Gravemaskine |
| Betonblander |
| Tømrer Tom |
| Murer Mads |
| Snedker Susanne |
| Maler Morten |
| VVS Victoria |

## Schedule

| ID | WBS | Task | Type | Duration | Start | Finish | Predecessors | Total slack | Free slack | Resources | Work | Cost |
| --- | --- | --- | --- | --- | --- | --- | --- | --- | --- | --- | --- | --- |
| 1 | 1 | Start | milestone | 0d | 2013-08-26 | 2013-08-26 |  | 1d | 0d |  |  |  |
| 2 | 2 | Tegning |  | 3d | 2013-08-26 | 2013-08-28 | 1 | 1d | 0d | Arkitekt Arne [50%] | 12h |  |
| 3 | 3 | **Fundament** |  | 7d | 2013-08-29 | 2013-09-07 | 2 | 0d |  |  | 48h | 1,000 |
| 4 | 3.1 | Udgravning |  | 2d | 2013-08-29 | 2013-08-30 |  | 1d | 0d | Gravemaskine; Jord og beton Jette | 32h |  |
| 5 | 3.2 | Støbning |  | 1d | 2013-09-02 | 2013-09-02 | 4 | 1d | 0d | Betonblander; Jord og beton Jette | 16h | 1,000 |
| 6 | 3.3 | Afbinding |  | 5ed | 2013-09-02 | 2013-09-07 | 5 | 4.88d |  |  |  |  |
| 7 | 4 | **Råhus** |  | 4.25d | 2013-09-09 | 2013-09-13 | 6 | 0d |  |  | 26h | 35,000 |
| 8 | 4.1 | Bærende konstruktioner |  | 3d | 2013-09-09 | 2013-09-11 |  | 0d |  | Tømrer Tom [25%] | 6h |  |
| 9 | 4.2 | Ydervægge |  | 2d | 2013-09-11 | 2013-09-13 | 8FS-2.5% | 0d |  | Murer Mads | 16h | 15,000 |
| 10 | 4.3 | Tag |  | 2d | 2013-09-11 | 2013-09-13 | 9SS | 0d |  | Tømrer Tom [25%] | 4h | 20,000 |
| 11 | 5 | Rejsegilde | milestone | 0d | 2013-09-13 | 2013-09-13 | 9, 10 | 0d |  |  |  |  |
| 12 | 6 | Taglægning |  | 10d | 2013-09-13 | 2013-09-27 | 11 | 0d |  | Tømrer Tom [50%] | 40h |  |
| 13 | 7 | Døre og vinduer |  | 2d | 2013-09-13 | 2013-09-17 | 12SS | 5d | 0d | Snedker Susanne [25%] | 4h |  |
| 14 | 8 | Faskine |  | 2d | 2013-09-03 | 2013-09-04 | 5 | 12d | 6.25d | Gravemaskine; Jord og beton Jette | 32h |  |
| 15 | 9 | Tagrender |  | 5h | 2013-09-13 | 2013-09-13 | 13SS, 14 | 5.75d | 0d | VVS Victoria [25%] | 1.25h |  |
| 16 | 10 | Maling udvendigt |  | 10h | 2013-09-13 | 2013-09-17 | 15 | 5.75d | 0.75d | Maler Morten | 10h |  |
| 17 | 11 | Gulv |  | 1d | 2013-09-17 | 2013-09-18 | 13, 16FS-5% | 5d |  | Snedker Susanne [25%] | 2h |  |
| 18 | 12 | Maling indvendigt |  | 2d | 2013-09-25 | 2013-09-27 | 12FF, 17 | 0d |  | Maler Morten | 16h |  |
| 19 | 13 | Indvielse | milestone | 0d | 2013-09-30 | 2013-09-30 | 13, 18FS+1d | 0d |  |  |  |  |
