# 13 - Føhn og Klæhm

Schedule from MS Project, 2015-03-16 to 2015-05-07, costs in kr..

## Calendars

- Standard: Mon-Fri 08:00-12:00, 13:00-17:00; Sat-Sun off.

## Resources

| Resource | Rate | Notes |
| --- | --- | --- |
| Arkitekt Arne | 600 |  |
| Murer Mads | 450 | Der er aftale en lønstigning |
| Jord og beton Jette | 400 | Der er aftale en lønstigning |
| Tømrer Tom | 475 |  |
| Snedker Susanne | 475 |  |
| Maler Morten | 450 | Der er aftale en lønstigning |
| VVS Victoria | 450 | Der er aftale en lønstigning |
| Gravemaskine | 600 |  |
| Betonblander | 150 |  |

## Schedule

| ID | WBS | Task | Type | Duration | Start | Finish | Predecessors | Total slack | Free slack | Resources | Work | Cost |
| --- | --- | --- | --- | --- | --- | --- | --- | --- | --- | --- | --- | --- |
| 1 | 1 | Tegning |  | 3d | 2015-03-16 | 2015-03-20 |  | 0d |  | Arkitekt Arne | 24h | 14,400 |
| 2 | 2 | Projektgodkendelse |  | 2d | 2015-03-20 | 2015-03-24 | 1 | 0d |  |  |  |  |
| 3 | 3 | Ansøgning om byggetilladelse |  | 5d | 2015-03-24 | 2015-03-31 | 2 | 0d |  |  |  |  |
| 4 | 4 | Byggesagsbehandling |  | 5d | 2015-03-31 | 2015-04-07 | 3 | 0d |  |  |  |  |
| 5 | 5 | **Fundament** |  | 6d | 2015-04-07 | 2015-04-15 | 4 | 0d |  |  | 48h | 21,400 |
| 6 | 5.1 | Udgravning |  | 2d | 2015-04-07 | 2015-04-09 |  | 0d |  | Jord og beton Jette; Gravemaskine | 32h | 16,000 |
| 7 | 5.2 | Støbning |  | 1d | 2015-04-09 | 2015-04-10 | 6 | 0d |  | Jord og beton Jette; Betonblander | 16h | 5,400 |
| 8 | 5.3 | Afbinding |  | 5ed | 2015-04-10 | 2015-04-15 | 7 | 0d |  |  |  |  |
| 9 | 6 | **Råhus** |  | 4.5d | 2015-04-15 | 2015-04-22 | 8 | 0d |  |  | 56h | 61,560 |
| 10 | 6.1 | Bærende konstruktioner |  | 3d | 2015-04-15 | 2015-04-20 |  | 0d |  | Tømrer Tom | 24h | 11,400 |
| 11 | 6.2 | Ydervægge |  | 2d | 2015-04-20 | 2015-04-21 | 10FS-2.5% | 0d |  | Murer Mads | 16h | 22,560 |
| 12 | 6.3 | Tagkonstruktioner |  | 2d | 2015-04-20 | 2015-04-22 | 11SS | 0d |  | Snedker Susanne | 16h | 27,600 |
| 13 | 7 | Rejsgilde | milestone | 0d | 2015-04-22 | 2015-04-22 | 12 | 0d |  | Arkitekt Arne; Jord og beton Jette; Maler Morten; Murer Mads; Snedker Susanne; Tømrer Tom; VVS Victoria |  |  |
| 14 | 8 | Taglægning |  | 10d | 2015-04-22 | 2015-05-06 | 13 | 0d |  | Tømrer Tom | 80h | 38,000 |
| 15 | 9 | Døre og vinduer |  | 2d | 2015-04-22 | 2015-04-24 | 14SS | 4.5d | 0d | Snedker Susanne | 16h | 7,600 |
| 16 | 10 | Faskine |  | 2d | 2015-04-10 | 2015-04-14 | 7 | 11.12d | 5.5d | Jord og beton Jette; Gravemaskine | 32h | 16,000 |
| 17 | 11 | Tagrender |  | 5h | 2015-04-22 | 2015-04-22 | 16, 15SS | 5.62d | 0d | VVS Victoria | 5h | 2,362.5 |
| 18 | 12 | Maling udvendigt |  | 10h | 2015-04-22 | 2015-04-24 | 17 | 5.62d | 1d | Maler Morten | 10h | 4,725 |
| 19 | 13 | Gulv |  | 1d | 2015-04-24 | 2015-04-27 | 18FS-5%, 15 | 4.62d |  | Snedker Susanne | 8h | 3,800 |
| 20 | 14 | Maling indvendigt |  | 2d | 2015-05-04 | 2015-05-06 | 19, 14FF | 0d |  | Maler Morten | 16h | 7,560 |
| 21 | 15 | Indvielse | milestone | 0d | 2015-05-07 | 2015-05-07 | 20FS+1d | 0d |  | Arkitekt Arne; Jord og beton Jette; Maler Morten; Murer Mads; Snedker Susanne; Tømrer Tom; VVS Victoria |  |  |
