# Ny butik i Århus

Schedule from MS Project, 2018-03-05 to 2018-04-05, costs in kr., A marks actual dates.
4D

## Calendars

- Standard: Mon-Fri 08:00-12:00, 13:00-17:00; Sat-Sun off.

## Resources

| Resource | Rate | Cost per use | Notes |
| --- | --- | --- | --- |
| Arkitekt Arne | 600 |  |  |
| Murer Mads | 472.5 |  | Du stiger i løn fra 6/-2018 |
| Jord og beton Jette | 420 |  | Du stiger i løn fra 6/-2018 |
| Tømrer Tom | 475 |  |  |
| Snedker Susanne | 475 |  |  |
| Maler Morten | 472.5 |  | Du stiger i løn fra 6/-2018 |
| VVS Victoria | 472.5 |  | Du stiger i løn fra 6/-2018 |
| Gravemaskine | 600 | 2000 |  |
| Betonblander | 150 | 1200 |  |

## Schedule

| ID | WBS | Task | Type | Duration | Start | Finish | Predecessors | Complete | Remaining | Total slack | Free slack | Resources | Work | Actual work | Cost | Actual cost |
| --- | --- | --- | --- | --- | --- | --- | --- | --- | --- | --- | --- | --- | --- | --- | --- | --- |
| 1 | 1 | Tegning |  | 3d | 2018-03-05 A | 2018-03-07 A |  | 100% |  |  |  | Arkitekt Arne | 24h | 24h | 14,400 | 14,400 |
| 2 | 2 | **Fundament** |  | 6d | 2018-03-12 A | 2018-03-19 | 1FS+2d | 54% | 2.75d | 0.5d |  |  | 48h | 36h | 24,600 | 19,250 |
| 3 | 2.1 | Udgravning |  | 2d | 2018-03-12 A | 2018-03-13 |  | 75% | 0.5d | 0.75d | 0d | Gravemaskine; Jord og beton Jette | 32h | 24h | 18,000 | 14,000 |
| 4 | 2.2 | Støbning |  | 1d | 2018-03-14 A | 2018-03-14 | 3 | 75% | 0.25d | 2d | 0d | Jord og beton Jette; Betonblander | 16h | 12h | 6,600 | 5,250 |
| 5 | 2.3 | Afbinding |  | 5ed | 2018-03-14 A | 2018-03-19 | 4 | 50% | 2.5ed | 2.5d | 1.88d |  |  |  |  |  |
| 6 | 3 | **Råhus** |  | 4d | 2018-03-20 A | 2018-03-23 | 5 | 6% | 3.75d | 9d |  |  | 64h | 4h | 65,000 | 5,550 |
| 7 | 3.1 | Bærende konstruktioner |  | 4d | 2018-03-20 | 2018-03-23 |  |  |  | 0.5d | 0d | Tømrer Tom | 32h |  | 15,200 |  |
| 8 | 3.2 | Ydervægge |  | 2d | 2018-03-22 A | 2018-03-23 | 7FS-5% | 25% | 1.5d | 9d | 0d | Murer Mads | 16h | 4h | 22,200 | 5,550 |
| 9 | 3.3 | Tagkonstruktioner |  | 2d | 2018-03-22 | 2018-03-23 | 8SS |  |  | 0d |  | Snedker Susanne | 16h |  | 27,600 |  |
| 10 | 4 | Rejsegilde | milestone | 0d | 2018-03-23 | 2018-03-23 | 9 |  |  | 0d |  | Arkitekt Arne; Jord og beton Jette; Maler Morten; Murer Mads; Snedker Susanne; Tømrer Tom; VVS Victoria |  |  |  |  |
| 11 | 5 | Taglægning |  | 8d | 2018-03-26 | 2018-04-04 | 10 |  |  | 0d |  | Tømrer Tom | 64h |  | 30,400 |  |
| 12 | 6 | Døre og vinduer |  | 2d | 2018-03-26 | 2018-03-27 | 11SS |  |  | 2d | 0d | Snedker Susanne | 16h |  | 7,600 |  |
| 13 | 7 | Faskine |  | 2d | 2018-03-15 A | 2018-03-16 A | 4 | 100% |  |  |  | Gravemaskine; Jord og beton Jette | 32h | 32h | 18,000 | 18,000 |
| 14 | 8 | Tagrender |  | 1d | 2018-03-26 | 2018-03-26 | 13, 12SS |  |  | 2d | 0d | VVS Victoria | 8h |  | 3,600 |  |
| 15 | 9 | Maling udvendigt |  | 2d | 2018-03-27 | 2018-03-28 | 14 |  |  | 2d | 0d | Maler Morten | 16h |  | 7,200 |  |
| 16 | 10 | Gulv |  | 2d | 2018-03-28 | 2018-03-29 | 15FS-5%, 12 |  |  | 2d |  | Snedker Susanne | 16h |  | 7,600 |  |
| 17 | 11 | Maling indvendigt |  | 2d | 2018-04-03 | 2018-04-04 | 16, 11FF |  |  | 0d |  | Maler Morten | 16h |  | 7,200 |  |
| 18 | 12 | Indvielse | milestone | 0d | 2018-04-05 | 2018-04-05 | 17FS+1d |  |  | 0d |  | Jord og beton Jette; Maler Morten; Murer Mads; Snedker Susanne; Tømrer Tom; VVS Victoria; Arkitekt Arne |  |  |  |  |
