# Butik i Hillerød

Schedule from MS Project, 2017-05-24 to 2017-06-27, costs in kr..

## Calendars

- Standard: Mon-Fri 08:00-12:00, 13:00-17:00; Sat-Sun off.

## Schedule

| ID | WBS | Task | Type | Duration | Start | Finish | Predecessors | Total slack | Free slack | Cost |
| --- | --- | --- | --- | --- | --- | --- | --- | --- | --- | --- |
| 1 | 1 | start | milestone | 0d | 2017-05-24 | 2017-05-24 |  | 0d |  |  |
| 2 | 2 | Tegning |  | 3d | 2017-05-24 | 2017-05-26 | 1 | 0d |  |  |
| 3 | 3 | **Fundament** |  | 6d | 2017-05-29 | 2017-06-05 | 2 | 0d |  | 1,000 |
| 4 | 3.1 | Udgravning |  | 2d | 2017-05-29 | 2017-05-30 |  | 0d |  |  |
| 5 | 3.2 | Støbning |  | 1d | 2017-05-31 | 2017-05-31 | 4 | 0d |  | 1,000 |
| 6 | 3.3 | Afbinding |  | 5ed | 2017-05-31 | 2017-06-05 | 5 | 1.88d |  |  |
| 7 | 4 | **Råhus** |  | 4.25d | 2017-06-06 | 2017-06-12 | 6 | 0d |  | 35,000 |
| 8 | 4.1 | Bærende konstruktioner |  | 3d | 2017-06-06 | 2017-06-08 |  | 0d |  |  |
| 9 | 4.2 | Ydervægge |  | 2d | 2017-06-08 | 2017-06-12 | 8FS-2.5% | 0d |  | 15,000 |
| 10 | 4.3 | Tag |  | 2d | 2017-06-08 | 2017-06-12 | 9SS | 0d |  | 20,000 |
| 11 | 5 | Rejsegilde | milestone | 0d | 2017-06-12 | 2017-06-12 | 10, 9 | 0d |  |  |
| 12 | 6 | Taglægning |  | 10d | 2017-06-12 | 2017-06-26 | 11 | 0d |  |  |
| 13 | 7 | Døre og vinduer |  | 2d | 2017-06-12 | 2017-06-14 | 12SS | 5d | 0d |  |
| 14 | 8 | Faskine |  | 2d | 2017-06-01 | 2017-06-02 | 5 | 11d | 5.25d |  |
| 15 | 9 | Tagrender |  | 5h | 2017-06-12 | 2017-06-12 | 14, 13SS | 5.75d | 0d |  |
| 16 | 10 | Maling udvendigt |  | 10h | 2017-06-12 | 2017-06-14 | 15 | 5.75d | 0.75d |  |
| 17 | 11 | Gulv |  | 1d | 2017-06-14 | 2017-06-15 | 16FS-5%, 13 | 5d |  |  |
| 18 | 12 | Maling indvendigt |  | 2d | 2017-06-22 | 2017-06-26 | 17, 12FF | 0d |  |  |
| 19 | 13 | Indvielse | milestone | 0d | 2017-06-27 | 2017-06-27 | 18FS+1d, 13 | 0d |  |  |
