# Butik i Næstved

Schedule from MS Project, 2017-06-24 to 2017-07-31, costs in kr..

## Calendars

- Standard: Mon-Fri 08:00-12:00, 13:00-17:00; Sat-Sun off.

## Schedule

| ID | WBS | Task | Type | Duration | Start | Finish | Predecessors | Total slack | Free slack | Cost |
| --- | --- | --- | --- | --- | --- | --- | --- | --- | --- | --- |
| 1 | 1 | start | milestone | 0d | 2017-06-24 | 2017-06-24 |  | 1d | 0d |  |
| 2 | 2 | Tegning |  | 3d | 2017-06-26 | 2017-06-28 | 1 | 1d | 0d |  |
| 3 | 3 | **Fundament** |  | 7d | 2017-06-29 | 2017-07-08 | 2 | 0d |  | 1,000 |
| 4 | 3.1 | Udgravning |  | 2d | 2017-06-29 | 2017-06-30 |  | 1d | 0d |  |
| 5 | 3.2 | Støbning |  | 1d | 2017-07-03 | 2017-07-03 | 4 | 1d | 0d | 1,000 |
| 6 | 3.3 | Afbinding |  | 5ed | 2017-07-03 | 2017-07-08 | 5 | 4.88d |  |  |
| 7 | 4 | **Råhus** |  | 4.25d | 2017-07-10 | 2017-07-14 | 6 | 0d |  | 35,000 |
| 8 | 4.1 | Bærende konstruktioner |  | 3d | 2017-07-10 | 2017-07-12 |  | 0d |  |  |
| 9 | 4.2 | Ydervægge |  | 2d | 2017-07-12 | 2017-07-14 | 8FS-2.5% | 0d |  | 15,000 |
| 10 | 4.3 | Tag |  | 2d | 2017-07-12 | 2017-07-14 | 9SS | 0d |  | 20,000 |
| 11 | 5 | Rejsegilde | milestone | 0d | 2017-07-14 | 2017-07-14 | 10, 9 | 0d |  |  |
| 12 | 6 | Taglægning |  | 10d | 2017-07-14 | 2017-07-28 | 11 | 0d |  |  |
| 13 | 7 | Døre og vinduer |  | 2d | 2017-07-14 | 2017-07-18 | 12SS | 5d | 0d |  |
| 14 | 8 | Faskine |  | 2d | 2017-07-04 | 2017-07-05 | 5 | 12d | 6.25d |  |
| 15 | 9 | Tagrender |  | 5h | 2017-07-14 | 2017-07-14 | 14, 13SS | 5.75d | 0d |  |
| 16 | 10 | Maling udvendigt |  | 10h | 2017-07-14 | 2017-07-18 | 15 | 5.75d | 0.75d |  |
| 17 | 11 | Gulv |  | 1d | 2017-07-18 | 2017-07-19 | 16FS-5%, 13 | 5d |  |  |
| 18 | 12 | Maling indvendigt |  | 2d | 2017-07-26 | 2017-07-28 | 17, 12FF | 0d |  |  |
| 19 | 13 | Indvielse | milestone | 0d | 2017-07-31 | 2017-07-31 | 18FS+1d, 13 | 0d |  |  |
