# Ny butik rapporter

Schedule from MS Project, 2008-09-23 to 2008-10-27, costs in kr, A marks actual dates.
VideoBuster A/S
Projektplan over byggeriet af den nye butik på Amagertorv. Butikken forventes klar til indvielse om to måneder.

## Calendars

- Standard: Mon-Fri 08:00-12:00, 13:00-17:00; Sat-Sun off.

## Resources

| Resource | Rate | Cost per use | Notes |
| --- | --- | --- | --- |
| Murer Mads | 472.5 |  | Der er indgående aftale om lønstigning på 5% med virkning fra 1 måned fra projektets startdato. |
| Jord og beton Jette | 420 |  | Der er indgående aftale om lønstigning på 5% med virkning fra 1 måned fra projektets startdato. |
| Tømrer Tom | 475 |  |  |
| Snedker Susanne | 475 |  |  |
| Maler Morten | 472.5 |  | Der er indgående aftale om lønstigning på 5% med virkning fra 1 måned fra projektets startdato. |
| VVS Victoria | 472.5 |  | Der er indgående aftale om lønstigning på 5% med virkning fra 1 måned fra projektets startdato. |
| Gravemaskine | 600 | 2000 |  |
| Betonblander | 150 | 1200 |  |
| Arkitekt Arne | 600 |  |  |

## Schedule

| ID | WBS | Task | Type | Duration | Start | Finish | Predecessors | Complete | Remaining | Total slack | Free slack | Resources | Work | Actual work | Cost | Actual cost |
| --- | --- | --- | --- | --- | --- | --- | --- | --- | --- | --- | --- | --- | --- | --- | --- | --- |
| 1 | 1 | Start | milestone | 0d | 2008-09-23 | 2008-09-23 |  |  |  | 24.5d |  |  |  |  |  |  |
| 2 | 2 | Tegning |  | 3d | 2008-09-23 A | 2008-09-25 A | 1 | 100% |  |  |  | Arkitekt Arne | 24h | 24h | 14,400 | 14,400 |
| 3 | 3 | **Fundament** |  | 6d | 2008-09-26 A | 2008-10-05 | 2 | 53% | 2.83d | 0.5d |  |  | 24h | 16h | 15,030 | 10,945 |
| 4 | 3.1 | Udgravning |  | 2d | 2008-09-26 A | 2008-09-29 |  | 75% | 0.5d | 0.5d | 0d | Jord og beton Jette; Gravemaskine | 16h | 12h | 9,320 | 7,490 |
| 5 | 3.2 | Støbning |  | 1d | 2008-09-30 A | 2008-09-30 | 4 | 50% | 0.5d | 2d | 0d | Jord og beton Jette; Betonblander | 8h | 4h | 5,710 | 3,455 |
| 6 | 3.3 | Afbinding |  | 5ed | 2008-09-30 A | 2008-10-05 | 5 | 50% | 2.5ed | 2.5d | 1.88d |  |  |  |  |  |
| 7 | 4 | **Råhus** |  | 4.5d | 2008-10-06 A | 2008-10-10 | 6 | 7% | 4.18d | 0d |  |  | 56h | 4h | 61,560 | 5,640 |
| 8 | 4.1 | Bærende konstruktioner |  | 3d | 2008-10-06 | 2008-10-08 |  |  |  | 0.5d | 0d | Tømrer Tom | 24h |  | 11,400 |  |
| 9 | 4.2 | Ydervægge |  | 2d | 2008-10-08 A | 2008-10-10 | 8FS-2.5% | 25% | 1.5d | 0.25d | 0d | Murer Mads | 16h | 4h | 22,560 | 5,640 |
| 10 | 4.3 | Tag |  | 2d | 2008-10-08 | 2008-10-10 | 9SS |  |  | 0d |  | Snedker Susanne | 16h |  | 27,600 |  |
| 11 | 5 | Rejsegilde | milestone | 0d | 2008-10-10 | 2008-10-10 | 10, 9 |  |  | 0d |  | Jord og beton Jette; Maler Morten; Murer Mads; Snedker Susanne; Tømrer Tom; VVS Victoria |  |  |  |  |
| 12 | 6 | Taglægning |  | 10d | 2008-10-10 | 2008-10-24 | 11 |  |  | 0d |  | Tømrer Tom | 80h |  | 38,000 |  |
| 13 | 7 | Døre og vinduer |  | 2d | 2008-10-10 | 2008-10-14 | 12SS |  |  | 4.62d | 0d | Snedker Susanne | 16h |  | 7,600 |  |
| 14 | 8 | Faskine |  | 2d | 2008-10-01 | 2008-10-02 | 5 |  |  | 11.12d | 5.5d | Jord og beton Jette; Gravemaskine | 16h |  | 9,320 |  |
| 15 | 9 | Tagrender |  | 5h | 2008-10-10 | 2008-10-13 | 14, 13SS |  |  | 5.62d | 0d | VVS Victoria | 5h |  | 2,362.5 |  |
| 16 | 10 | Maling udvendigt |  | 10h | 2008-10-13 | 2008-10-14 | 15 |  |  | 5.62d | 1d | Maler Morten | 10h |  | 4,725 |  |
| 17 | 11 | Gulv |  | 1d | 2008-10-14 | 2008-10-15 | 16FS-5%, 13 |  |  | 4.62d |  | Snedker Susanne | 8h |  | 3,800 |  |
| 18 | 12 | Maling indvendigt |  | 2d | 2008-10-22 | 2008-10-24 | 17, 12FF |  |  | 0d |  | Maler Morten | 16h |  | 7,560 |  |
| 19 | 13 | Indvielse | milestone | 0d | 2008-10-27 | 2008-10-27 | 18FS+1d, 13 |  |  | 0d |  | Jord og beton Jette; Maler Morten; Murer Mads; Snedker Susanne; Tømrer Tom; VVS Victoria |  |  |  |  |
